# MSProject Self-Assessment Project

Schedule from MS Project, 2016-10-31 to 2017-01-19, costs in £.
AbleSim Ltd
Time Objective: 3 months / Cost Objective: £12,500 / Functionality Objectives: Arrange a conference with gust speaker for 100 delegates

## Calendars

- Standard: Mon-Fri 08:00-12:00, 13:00-17:00; Sat-Sun off. Exceptions (off unless hours are given): 2016-12-26 to 2016-12-27 (Christmas Break), 2017-01-02 (New Year Holiday).

## Resources

| Resource | Rate |
| --- | --- |
| Manager | 20 |
| Assistant | 10 |
| Marketing Staff | 50 |
| Photocopier |  |
| Paper | 0.01 |
| Driver | 8 |

## Schedule

| ID | WBS | Task | Type | Duration | Start | Finish | Predecessors | Baseline start | Baseline finish | Baseline duration | Total slack | Free slack | Resources | Work | Cost | Baseline cost |
| --- | --- | --- | --- | --- | --- | --- | --- | --- | --- | --- | --- | --- | --- | --- | --- | --- |
| 1 | 1 | **CONFERENCE** |  | 55.17d | 2016-10-31 | 2017-01-19 |  | 2016-10-31 | 2017-01-19 | 55.17d | 0d |  |  | 242h | 14,702 | 14,702 |
| 2 | 1.1 | **SPEAKERS** |  | 18d | 2016-10-31 | 2016-11-23 |  | 2016-10-31 | 2016-11-23 | 18d | 0d |  |  | 46h | 720 | 720 |
| 3 | 1.1.1 | Start Project | milestone | 0d | 2016-10-31 | 2016-10-31 |  | 2016-10-31 | 2016-10-31 |  | 0d |  |  |  |  |  |
| 4 | 1.1.2 | Decide Topics |  | 5d | 2016-10-31 | 2016-11-04 | 3 | 2016-10-31 | 2016-11-04 | 5d | 8d | 0d | Manager | 6h | 120 | 120 |
| 5 | 1.1.3 | Decide Speakers |  | 3d | 2016-11-07 | 2016-11-09 | 4 | 2016-11-07 | 2016-11-09 | 3d | 8d | 0d | Manager | 12h | 240 | 240 |
| 6 | 1.1.4 | Arrange Speakers |  | 5d | 2016-11-10 | 2016-11-16 | 5 | 2016-11-10 | 2016-11-16 | 5d | 8d | 0d | Assistant | 20h | 200 | 200 |
| 7 | 1.1.5 | Brief Speakers |  | 5d | 2016-11-17 | 2016-11-23 | 6 | 2016-11-17 | 2016-11-23 | 5d | 8d |  | Manager | 8h | 160 | 160 |
| 8 | 1.2 | **VENUE** |  | 22d | 2016-10-31 | 2016-11-29 |  | 2016-10-31 | 2016-11-29 | 22d | 0d |  |  | 64h | 11,680 | 11,680 |
| 9 | 1.2.1 | Decide Venue |  | 10d | 2016-10-31 | 2016-11-11 | 3 | 2016-10-31 | 2016-11-11 | 10d | 0d |  | Manager; Assistant | 40h | 440 | 440 |
| 10 | 1.2.2 | Book Venue |  | 2d | 2016-11-14 | 2016-11-15 | 9 | 2016-11-14 | 2016-11-15 | 2d | 0d |  | Assistant | 8h | 10,080 | 10,080 |
| 11 | 1.2.3 | Arrange Catering |  | 10d | 2016-11-16 | 2016-11-29 | 10 | 2016-11-16 | 2016-11-29 | 10d | 4d |  | Assistant | 16h | 1,160 | 1,160 |
| 12 | 1.3 | **MARKETING** |  | 14d | 2016-11-16 | 2016-12-05 |  | 2016-11-16 | 2016-12-05 | 14d | 0d |  |  | 39h | 450 | 450 |
| 13 | 1.3.1 | Decide Flyers |  | 10d | 2016-11-16 | 2016-11-29 | 10 | 2016-11-16 | 2016-11-29 | 10d | 0d |  | Manager; Assistant | 20h | 300 | 300 |
| 14 | 1.3.2 | Print Flyers |  | 1d | 2016-11-30 | 2016-11-30 | 13 | 2016-11-30 | 2016-11-30 | 1d | 0d |  | Assistant; Photocopier | 8h | 40 | 40 |
| 15 | 1.3.3 | Mail Flyers |  | 2d | 2016-12-01 | 2016-12-02 | 14 | 2016-12-01 | 2016-12-02 | 2d | 0d |  | Assistant | 8h | 80 | 80 |
| 16 | 1.3.4 | Update Twitter |  | 0.5d | 2016-12-05 | 2016-12-05 | 15 | 2016-12-05 | 2016-12-05 | 0.5d | 0d |  | Assistant | 1h | 10 | 10 |
| 17 | 1.3.5 | Send Email Reminders |  | 0.5d | 2016-12-05 | 2016-12-05 | 16 | 2016-12-05 | 2016-12-05 | 0.5d | 0d |  | Assistant | 2h | 20 | 20 |
| 18 | 1.4 | **REGISTRATION** |  | 29.17d | 2016-12-06 | 2017-01-19 |  | 2016-12-06 | 2017-01-19 | 29.17d | 0d |  |  | 80h | 1,160 | 1,160 |
| 19 | 1.4.1 | Create Register |  | 2d | 2016-12-06 | 2016-12-07 | 11, 17, 7 | 2016-12-06 | 2016-12-07 | 2d | 0d |  | Assistant | 4h | 40 | 40 |
| 20 | 1.4.2 | Register Applicants |  | 1.67d | 2016-12-08 | 2016-12-09 | 19 | 2016-12-08 | 2016-12-09 | 1.67d | 0d |  | Assistant | 8h | 80 | 80 |
| 21 | 1.4.3 | Send Confirmation |  | 10d | 2016-12-09 | 2016-12-23 | 20 | 2016-12-09 | 2016-12-23 | 10d | 0d |  | Assistant | 8h | 80 | 80 |
| 22 | 1.4.4 | Arrange Banking |  | 5d | 2016-12-23 | 2017-01-04 | 21 | 2016-12-23 | 2017-01-04 | 5d | 0d |  | Assistant | 20h | 200 | 200 |
| 23 | 1.4.5 | Obtain Approval |  | 0.5d | 2017-01-04 | 2017-01-05 | 22 | 2017-01-04 | 2017-01-05 | 0.5d | 0d |  | Manager; Assistant | 8h | 120 | 120 |
| 24 | 1.4.6 | Hold Event | milestone | 0d | 2017-01-05 | 2017-01-05 | 23 | 2017-01-05 | 2017-01-05 |  | 0d |  |  |  |  |  |
| 25 | 1.4.7 | Balance Accounts |  | 10d | 2017-01-05 | 2017-01-19 | 30, 24 | 2017-01-05 | 2017-01-19 | 10d | 0d |  | Manager | 32h | 640 | 640 |

| ID | WBS | Task | Duration | Start | Finish | Predecessors | Baseline start | Baseline finish | Baseline duration | Total slack | Free slack | Resources | Work | Cost | Baseline cost |
| --- | --- | --- | --- | --- | --- | --- | --- | --- | --- | --- | --- | --- | --- | --- | --- |
| 26 | 1.5 | **SPEAKER ACCOMMODATION** | 4d | 2016-11-17 | 2016-11-22 |  | 2016-11-17 | 2016-11-22 | 4d | 28.17d |  |  | 13h | 692 | 692 |
| 27 | 1.5.1 | Confirm Arrival Flight | 1d | 2016-11-17 | 2016-11-17 | 6 | 2016-11-17 | 2016-11-17 | 1d | 28.17d | 0d | Assistant; Manager | 8h | 120 | 120 |
| 28 | 1.5.2 | Book Hotel | 1d | 2016-11-18 | 2016-11-18 | 27 | 2016-11-18 | 2016-11-18 | 1d | 28.17d | 0d | Manager | 2h | 540 | 540 |
| 29 | 1.5.3 | Arrange Collection from Airport | 1d | 2016-11-21 | 2016-11-21 | 28 | 2016-11-21 | 2016-11-21 | 1d | 28.17d | 0d | Manager; Driver | 1h | 14 | 14 |
| 30 | 1.5.4 | Arrange Car to Venue | 1d | 2016-11-22 | 2016-11-22 | 29 | 2016-11-22 | 2016-11-22 | 1d | 28.17d |  | Assistant; Driver | 2h | 18 | 18 |
